# Shutdown 09

Schedule from MS Project, 2009-06-15 to 2009-09-23, 6 hours a day.
Fermi

## Calendars

- Standard: Mon-Fri 07:00-12:00, 13:00-13:30; Sat-Sun off.

## Resources

| Resource | Rate |
| --- | --- |
| weldor |  |
| 3tcrew1 |  |
| 3tcrew2 |  |
| 3tcrew3 |  |
| 3S Survey crew |  |
| ele tech |  |
| 2watertech |  |
| Surveyor3 |  |
| Pipe Crew 1 | 160 |
| Pipe Crew 2 | 160 |
| Pipe Crew 3 | 160 |
| Pipe Crew 4 | 160 |
| Superintendant | 80 |
| ORBW1 | 75 |
| ORBW2 | 75 |
| PipeC1 | 15 |
| PipeC2 | 15 |
| ORBW3 | 75 |
| PipeC3 | 15 |
| 9 |  |
| 10 |  |
| 633 |  |
| 634 |  |
| 635 |  |
| 636 |  |
| 638 |  |
| 639 |  |
| 640 |  |
| 641 |  |
| 643 |  |
| 644 |  |
| 645 |  |
| 646 |  |
| 648 |  |
| 649 |  |
| 650 |  |
| 651 |  |
| 653 |  |
| 654 |  |
| 655 |  |
| 656 |  |
| 658 |  |
| 659 |  |
| 660 |  |
| 661 |  |
| 663 |  |
| 664 |  |
| 665 |  |
| 666 |  |
| 667 |  |
| 668 |  |
| 669 |  |
| 670 |  |
| 674 |  |
| 676 |  |
| 677 |  |
| 678 |  |
| 679 |  |
| 680 |  |
| 681 |  |
| 683 |  |
| 684 |  |
| 685 |  |
| 686 |  |
| 687 |  |
| 688 |  |
| 690 |  |
| 691 |  |
| 692 |  |
| 693 |  |
| 694 |  |
| 695 |  |
| 697 |  |
| 698 |  |
| 699 |  |
| 700 |  |
| 701 |  |
| 702 |  |
| 704 |  |
| 705 |  |
| 706 |  |
| 707 |  |
| 708 |  |
| 709 |  |
| 711 |  |
| 712 |  |
| 713 |  |
| 714 |  |
| 715 |  |
| 716 |  |
| 718 |  |
| 719 |  |
| 720 |  |
| 721 |  |
| 722 |  |
| 723 |  |
| 724 |  |
| 725 |  |
| 726 |  |
| 727 |  |
| 728 |  |
| 729 |  |
| 730 |  |
| 731 |  |
| 733 |  |
| 734 |  |

## Schedule

| ID | WBS | Task | Duration | Start | Finish | Predecessors | Total slack | Free slack |
| --- | --- | --- | --- | --- | --- | --- | --- | --- |
| 1 | 1 | Shutdown Dates | 10w | 2009-06-15 07:00 | 2009-09-23 11:00 |  | 0d |  |
| 3 | 2 | **Main Injector** | 60.75d | 2009-06-15 07:00 | 2009-09-15 08:30 |  | 5.92d |  |
| 4 | 2.1 | **Nova Construction** | 60.75d | 2009-06-15 07:00 | 2009-09-15 08:30 |  | 5.92d |  |
| 5 | 2.1.1 | **MI 39 Penetrations** | 55.75d | 2009-06-15 07:00 | 2009-09-07 11:30 |  | 10.92d |  |
| 6 | 2.1.1.1 | Stage equipment | 4h | 2009-06-15 07:00 | 2009-06-15 11:00 |  | 27.25d | 0d |
| 7 | 2.1.1.2 | Isolate and disconnect LCW from Lambertsons | 1h | 2009-06-15 11:00 | 2009-06-15 12:00 | 6 | 27.25d | 0d |
| 8 | 2.1.1.3 | Install Heat Blankets on Lambertsons | 1h | 2009-06-15 13:00 | 2009-06-16 07:30 | 7 | 27.25d | 0d |
| 9 | 2.1.1.4 | Install Lead blankets | 4h | 2009-06-16 07:30 | 2009-06-16 11:30 | 8 | 27.25d | 0d |
| 10 | 2.1.1.5 | Disconnect cables from MI and Rec kickers | 2h | 2009-06-16 11:30 | 2009-06-17 08:00 | 9 | 64.67d |  |
| 11 | 2.1.1.6 | Roll up 12 cablescable and store out of way | 5h | 2009-06-16 11:30 | 2009-06-17 11:00 | 9 | 27.25d | 0d |
| 12 | 2.1.1.7 | Remove kicker cable tray, ground wire, and supports, store close by | 2d | 2009-06-17 11:00 | 2009-06-19 12:00 | 11 | 27.25d | 0d |
| 13 | 2.1.1.8 | Install Herculite in Pan area | 0.5h | 2009-06-17 11:00 | 2009-06-17 11:30 | 12SS | 27.25d | 0d |
| 14 | 2.1.1.9 | Install pan first location to ceiling | 2h | 2009-06-17 11:30 | 2009-06-18 08:00 | 13 | 27.25d | 0d |
| 15 | 2.1.1.10 | Install Herculite in Pan area | 0.5h | 2009-06-18 08:00 | 2009-06-18 08:30 | 14 | 27.25d | 0d |
| 16 | 2.1.1.11 | Install pan 2nd location to ceiling | 2h | 2009-06-18 08:30 | 2009-06-18 10:30 | 15 | 27.25d | 0d |
| 17 | 2.1.1.12 | Install Herculite in Pan area | 0.5h | 2009-06-18 10:30 | 2009-06-18 11:00 | 16 | 27.25d | 0d |
| 18 | 2.1.1.13 | Install pan 3rd location to ceiling | 2h | 2009-06-18 11:00 | 2009-06-19 07:30 | 17 | 27.25d | 0d |
| 19 | 2.1.1.14 | Install Herculite in Pan area | 0.5h | 2009-06-19 07:30 | 2009-06-19 08:00 | 18 | 27.25d | 0d |
| 20 | 2.1.1.15 | Install pan 4th location to ceiling | 2h | 2009-06-19 08:00 | 2009-06-19 10:00 | 19 | 27.25d | 0d |
| 21 | 2.1.1.16 | Install Herculite in Pan area | 0.5h | 2009-06-19 10:00 | 2009-06-19 10:30 | 20 | 27.25d | 0d |
| 22 | 2.1.1.17 | Install pan 5th location to ceiling | 2h | 2009-06-19 10:30 | 2009-06-19 13:30 | 21 | 27.25d | 0d |
| 23 | 2.1.1.18 | Install Herculite in Pan area | 0.5h | 2009-06-22 07:00 | 2009-06-22 07:30 | 22 | 27.25d | 0d |
| 24 | 2.1.1.19 | Install pan 6th location to ceiling | 2h | 2009-06-22 07:30 | 2009-06-22 09:30 | 23 | 27.25d | 0d |
| 25 | 2.1.1.20 | remove pan first location from ceiling | 1h | 2009-07-14 10:00 | 2009-07-14 11:00 | 98 | 45.42d | 0d |
| 26 | 2.1.1.21 | remove Herculite from first Pan area | 30min | 2009-07-14 11:00 | 2009-07-14 11:30 | 25 | 45.42d | 0d |
| 27 | 2.1.1.22 | remove pan secondt location from ceiling | 1h | 2009-07-14 11:30 | 2009-07-14 13:30 | 26 | 45.42d | 0d |
| 28 | 2.1.1.23 | remove Herculite from second Pan area | 30min | 2009-07-15 07:00 | 2009-07-15 07:30 | 27 | 45.42d | 0d |
| 29 | 2.1.1.24 | remove pan third location from ceiling | 1h | 2009-07-15 07:30 | 2009-07-15 08:30 | 28 | 45.42d | 0d |
| 30 | 2.1.1.25 | remove Herculite from third Pan area | 30min | 2009-07-15 08:30 | 2009-07-15 09:00 | 29 | 45.42d | 0d |
| 31 | 2.1.1.26 | remove pan forth location from ceiling | 1h | 2009-07-15 09:00 | 2009-07-15 10:00 | 30 | 45.42d | 0d |
| 32 | 2.1.1.27 | remove Herculite from forth Pan area | 30min | 2009-07-15 10:00 | 2009-07-15 10:30 | 31 | 45.42d | 0d |
| 33 | 2.1.1.28 | remove pan fifth location from ceiling | 1h | 2009-07-15 10:30 | 2009-07-15 11:30 | 32 | 45.42d | 0d |
| 34 | 2.1.1.29 | remove Herculite from fifth Pan area | 30min | 2009-07-15 11:30 | 2009-07-15 12:00 | 33 | 45.42d | 0d |
| 35 | 2.1.1.30 | remove pan sixth location from ceiling | 1h | 2009-07-15 13:00 | 2009-07-16 07:30 | 34 | 45.42d | 0d |
| 36 | 2.1.1.31 | remove Herculite from sixth Pan area | 30min | 2009-07-16 07:30 | 2009-07-16 08:00 | 35 | 45.42d |  |
| 37 | 2.1.1.32 | reinstall cable tray | 2d | 2009-08-05 13:00 | 2009-08-10 07:30 | 100 | 7.48d | 0d |
| 38 | 2.1.1.33 | reinstall cables | 6.6h | 2009-08-10 07:30 | 2009-08-11 08:36 | 37 | 7.48d | 0d |
| 39 | 2.1.1.34 | Reconnect Rec and Mi Kickers | 4h | 2009-08-11 08:36 | 2009-08-12 07:06 | 38 | 28.15d |  |
| 40 | 2.1.1.35 | Remove Lead blankets | 8h | 2009-07-20 13:00 | 2009-07-22 09:00 | 81 | 41.58d |  |
| 41 | 2.1.1.36 | As found survey MI39 MI and RR areas | 5d | 2009-08-20 11:30 | 2009-08-28 08:30 | 103 | 11.92d | 0d |
| 42 | 2.1.1.37 | Final Sheilding survey to run beam | 1d | 2009-09-04 11:00 | 2009-09-07 11:30 | 94, 105 | 10.92d |  |

| ID | WBS | Task | Duration | Start | Finish | Predecessors | Total slack | Free slack |
| --- | --- | --- | --- | --- | --- | --- | --- | --- |
| 43 | 2.1.2 | **MI 40 Kickers** | 20.25d | 2009-06-22 09:30 | 2009-07-22 10:00 | 24 | 27.25d |  |
| 44 | 2.1.2.1 | Vent vacuum | 1h | 2009-06-22 09:30 | 2009-06-22 10:30 |  | 61.5d |  |
| 45 | 2.1.2.2 | Remove spool us of existing kickers to vac valve | 30min | 2009-06-22 09:30 | 2009-06-22 10:00 |  | 27.25d | 0d |
| 46 | 2.1.2.3 | Remove beam tube sect DS of Kickers to Q401 corrector | 1h | 2009-06-22 10:00 | 2009-06-22 11:00 | 45 | 27.25d | 0d |
| 47 | 2.1.2.4 | Remove beam tube stands | 1h | 2009-06-22 11:00 | 2009-06-22 12:00 | 46 | 27.25d | 0d |
| 48 | 2.1.2.5 | Remove spool between existing kickers | 30min | 2009-06-22 13:00 | 2009-06-22 13:30 | 47 | 27.25d | 0d |
| 49 | 2.1.2.6 | Remove existing kicker and place on cribbing | 1h | 2009-06-23 07:00 | 2009-06-23 08:00 | 48 | 27.25d | 0d |
| 50 | 2.1.2.7 | Remove existing kicker and place on cribbing | 1h | 2009-06-23 08:00 | 2009-06-23 09:00 | 49 | 27.25d | 0d |
| 51 | 2.1.2.8 | Stake new stand locations x 11 | 8h | 2009-06-23 09:00 | 2009-06-24 11:30 | 50 | 27.25d | 0d |
| 52 | 2.1.2.9 | Install kicker 1 stand | 2h | 2009-06-24 11:30 | 2009-06-25 08:00 | 51 | 27.25d | 0d |
| 53 | 2.1.2.10 | Install kicker 2 stand | 2h | 2009-06-25 08:00 | 2009-06-25 10:00 | 52 | 27.25d | 0d |
| 54 | 2.1.2.11 | Install kicker 3 stand | 2h | 2009-06-25 10:00 | 2009-06-25 12:00 | 53 | 27.25d | 0d |
| 55 | 2.1.2.12 | Install kicker 4 stand | 2h | 2009-06-25 13:00 | 2009-06-26 08:30 | 54 | 27.25d | 0d |
| 56 | 2.1.2.13 | Install kicker 5 stand | 2h | 2009-06-26 08:30 | 2009-06-26 10:30 | 55 | 27.25d | 0d |
| 57 | 2.1.2.14 | Install kicker 6 stand | 2h | 2009-06-26 10:30 | 2009-06-26 13:30 | 56 | 27.25d | 0d |
| 58 | 2.1.2.15 | Install kicker 7 stand | 2h | 2009-06-29 07:00 | 2009-06-29 09:00 | 57 | 27.25d | 0d |
| 59 | 2.1.2.16 | Install stands for one existing kicker x2 | 2h | 2009-06-29 09:00 | 2009-06-29 11:00 | 58 | 27.25d | 0d |
| 60 | 2.1.2.17 | Install stands for the other existing kicker x 2 | 2h | 2009-06-29 11:00 | 2009-06-30 07:30 | 59 | 27.25d | 0d |
| 61 | 2.1.2.18 | Install existing kicker 1 | 1h | 2009-06-30 07:30 | 2009-06-30 08:30 | 60 | 27.25d | 0d |
| 62 | 2.1.2.19 | Install existing Kicker 2 | 1h | 2009-06-30 08:30 | 2009-06-30 09:30 | 61 | 27.25d | 0d |
| 63 | 2.1.2.20 | Install new kicker 1 | 1h | 2009-06-30 09:30 | 2009-06-30 10:30 | 62 | 27.25d | 0d |
| 64 | 2.1.2.21 | Install New Kicker 2 | 1h | 2009-06-30 10:30 | 2009-06-30 11:30 | 63 | 27.25d | 0d |
| 65 | 2.1.2.22 | Install New Kicker 3 | 1h | 2009-06-30 11:30 | 2009-06-30 13:30 | 64 | 27.25d | 0d |
| 66 | 2.1.2.23 | Install New Kicker 4 | 1h | 2009-07-01 07:00 | 2009-07-01 08:00 | 65 | 27.25d | 0d |
| 67 | 2.1.2.24 | Install New Kicker 5 | 1h | 2009-07-01 08:00 | 2009-07-01 09:00 | 66 | 27.25d | 0d |
| 68 | 2.1.2.25 | Install New Kicker 6 | 1h | 2009-07-01 09:00 | 2009-07-01 10:00 | 67 | 27.25d | 0d |
| 69 | 2.1.2.26 | Install New Kicker 7 | 1h | 2009-07-01 10:00 | 2009-07-01 11:00 | 68 | 27.25d | 0d |
| 70 | 2.1.2.27 | Install spool, Ion pump, Ion pump stand, gauge and valve | 2h | 2009-07-01 11:00 | 2009-07-02 07:30 | 69 | 27.25d | 0d |
| 71 | 2.1.2.28 | Install spool between old kickers | 30min | 2009-07-02 07:30 | 2009-07-02 08:00 | 70 | 27.25d | 0d |
| 72 | 2.1.2.29 | Install ion pump and tee ds of old kickers | 2h | 2009-07-02 08:00 | 2009-07-02 10:00 | 71 | 27.25d | 0d |
| 73 | 2.1.2.30 | Install ds ion pump, tee, connect to kicker | 2h | 2009-07-02 10:00 | 2009-07-02 12:00 | 72 | 27.25d | 0d |
| 74 | 2.1.2.31 | weld on cone and connect | 2h | 2009-07-02 13:00 | 2009-07-03 08:30 | 73 | 27.25d | 0d |
| 75 | 2.1.2.32 | Survey straight section | 10h | 2009-07-03 08:30 | 2009-07-07 07:30 | 74 | 27.25d | 0d |
| 76 | 2.1.2.33 | Change 2 ion pumps on Lambertsons | 2h | 2009-07-07 07:30 | 2009-07-07 09:30 | 75 | 27.25d | 0d |
| 77 | 2.1.2.34 | Connect vacuum system | 6h | 2009-07-07 09:30 | 2009-07-08 10:00 | 76 | 27.25d | 0d |
| 78 | 2.1.2.35 | Pump out and leak check | 8h | 2009-07-08 10:00 | 2009-07-09 13:30 | 77 | 27.25d | 0d |
| 79 | 2.1.2.36 | Bake set up | 4h | 2009-07-10 07:00 | 2009-07-10 11:00 | 78 | 27.25d | 0d |
| 80 | 2.1.2.37 | Bake Lambertsons | 5d | 2009-07-10 11:00 | 2009-07-20 08:00 | 79 | 41.42d | 0d |
| 81 | 2.1.2.38 | Bake tear down | 4h | 2009-07-20 08:00 | 2009-07-20 12:00 | 80 | 41.42d | 0d |
| 82 | 2.1.2.39 | Post bake leak check | 4h | 2009-07-20 13:00 | 2009-07-21 10:30 | 81 | 41.42d | 0d |
| 83 | 2.1.2.40 | Reconnect LCW | 1h | 2009-07-21 10:30 | 2009-07-21 11:30 | 82 | 41.42d | 0d |
| 84 | 2.1.2.41 | Turn on ion pumps | 4h | 2009-07-21 11:30 | 2009-07-22 10:00 | 83 | 41.42d |  |

| ID | WBS | Task | Duration | Start | Finish | Predecessors | Total slack | Free slack | Constraint |
| --- | --- | --- | --- | --- | --- | --- | --- | --- | --- |
| 85 | 2.1.3 | **T&M pipefitters MI39 Flourinert system** | 21.33d | 2009-08-11 08:36 | 2009-09-11 10:06 | 79, 37, 38 | 7.48d |  |  |
| 86 | 2.1.3.1 | Stage equipment, supplies | 1.33d | 2009-08-11 08:36 | 2009-08-12 11:06 |  | 7.48d | 0d |  |
| 87 | 2.1.3.2 | Install unistrut, pipe hangers | 4d | 2009-08-12 11:06 | 2009-08-19 07:36 | 86 | 7.48d | 0d |  |
| 88 | 2.1.3.3 | Fit, weld, install pipe | 10.67d | 2009-08-19 07:36 | 2009-09-03 11:06 | 87 | 7.48d | 0d |  |
| 89 | 2.1.3.4 | Leak check pipe | 4d | 2009-09-03 11:06 | 2009-09-10 07:36 | 88 | 7.48d | 0d |  |
| 90 | 2.1.3.5 | Remove from tunnel | 1.33d | 2009-09-10 07:36 | 2009-09-11 10:06 | 89 | 7.48d |  |  |
| 91 | 2.1.3.6 | Fermi elec instrument techs | 6.67d | 2009-08-11 08:36 | 2009-08-20 10:06 |  | 19.48d | 0d |  |
| 92 | 2.1.3.7 | Complete Installation | 2.67d | 2009-08-20 10:06 | 2009-08-25 09:36 | 91 | 19.48d |  |  |
| 93 | 2.1.4 | **Contractor MI39 area** | 52d | 2009-06-18 07:00 | 2009-09-04 11:00 |  | 5.92d |  |  |
| 94 | 2.1.4.1 | **Conduit Installation** | 42d | 2009-06-18 07:00 | 2009-08-20 11:30 |  | 5.92d |  |  |
| 95 | 2.1.4.1.1 | Remove topsoil | 2d | 2009-06-18 07:00 | 2009-06-22 08:00 |  | 5.92d | 0d | start no earlier than 2009-06-18 07:00 |
| 96 | 2.1.4.1.2 | Start Civil Construction | 5d | 2009-06-22 08:00 | 2009-06-29 10:30 | 95 | 5.92d | 0d |  |
| 97 | 2.1.4.1.3 | Vacate Mi39 area in tunnel | 1d | 2009-06-26 10:00 | 2009-06-29 10:30 | 96SS+4d | 7.48d | 0d |  |
| 98 | 2.1.4.1.4 | Core holes in Ceiling | 10d | 2009-06-29 10:30 | 2009-07-14 10:00 | 97 | 7.48d | 0d |  |
| 99 | 2.1.4.1.5 | Install support frames | 10d | 2009-07-14 10:00 | 2009-07-29 09:30 | 98 | 7.48d | 0d |  |
| 100 | 2.1.4.1.6 | Install 12 conduits | 10d | 2009-07-22 07:00 | 2009-08-05 12:00 | 99SS+5d | 7.48d | 0d |  |
| 101 | 2.1.4.1.7 | FBP Enclosure Cap beams | 5d | 2009-07-22 07:00 | 2009-07-29 09:30 | 100SS | 10.92d | 0d |  |
| 102 | 2.1.4.1.8 | Water proof top of enclosure | 5d | 2009-07-29 09:30 | 2009-08-05 12:00 | 101 | 10.92d | 0d |  |
| 103 | 2.1.4.1.9 | Backfill berm | 10d | 2009-08-05 13:00 | 2009-08-20 11:30 | 102 | 10.92d | 0d |  |
| 104 | 2.1.4.1.10 | Vacate MI39 area in tunnel | 1d | 2009-08-07 07:00 | 2009-08-10 07:30 | 103SS+1d | 28.92d |  |  |
| 105 | 2.1.4.2 | **Concrete Foundation installation** | 20d | 2009-08-05 13:00 | 2009-09-04 11:00 |  | 10.92d | 0d |  |
| 106 | 2.1.4.2.1 | FBP Deep Footing | 5d | 2009-08-05 13:00 | 2009-08-13 09:00 | 103SS | 10.92d | 0d |  |
| 107 | 2.1.4.2.2 | FBP Deep Well | 5d | 2009-08-13 09:00 | 2009-08-20 11:30 | 106 | 10.92d | 0d |  |
| 108 | 2.1.4.2.3 | FBP Remaining Footing | 5d | 2009-08-13 09:00 | 2009-08-20 11:30 | 107SS | 10.92d | 0d |  |
| 109 | 2.1.4.2.4 | FBP Remining Walls | 5d | 2009-08-20 11:30 | 2009-08-28 08:30 | 108 | 10.92d | 0d |  |
| 110 | 2.1.4.2.5 | Backfill and Install underslab conduits | 5d | 2009-08-28 08:30 | 2009-09-04 11:00 | 109 | 10.92d |  |  |
| 111 | 2.1.4.2.6 | Construction of foundation and floor slabs MI39 Bldg | 10d | 2009-08-05 13:00 | 2009-08-20 11:30 | 103SS | 20.92d |  |  |

| ID | WBS | Task | Duration | Start | Finish | Predecessors | Total slack | Free slack |
| --- | --- | --- | --- | --- | --- | --- | --- | --- |
| 112 | 2.1.5 | **MI14 Penetrations** | 60.75d | 2009-06-15 07:00 | 2009-09-15 08:30 |  | 5.92d |  |
| 113 | 2.1.5.1 | As found survey MI and RR | 3d | 2009-06-15 07:00 | 2009-06-18 08:30 |  | 62.33d | 0d |
| 114 | 2.1.5.2 | Install lead blankets | 6h | 2009-06-15 07:00 | 2009-06-16 07:30 | 113SS | 62.33d | 0d |
| 115 | 2.1.5.3 | Install Herculite in Pan area | 30min | 2009-06-16 07:30 | 2009-06-16 08:00 | 114 | 62.33d | 0d |
| 116 | 2.1.5.4 | Install pan first location to ceiling | 2h | 2009-06-16 08:00 | 2009-06-16 10:00 | 115 | 62.33d | 0d |
| 117 | 2.1.5.5 | Install Herculite in Pan area | 30min | 2009-06-16 10:00 | 2009-06-16 10:30 | 116 | 62.33d | 0d |
| 118 | 2.1.5.6 | Install pan 2nd location to ceiling | 2h | 2009-06-16 10:30 | 2009-06-16 13:30 | 117 | 62.33d | 0d |
| 119 | 2.1.5.7 | Install Herculite in Pan area | 30min | 2009-06-17 07:00 | 2009-06-17 07:30 | 118 | 62.33d | 0d |
| 120 | 2.1.5.8 | Install pan 3rd location to ceiling | 2h | 2009-06-17 07:30 | 2009-06-17 09:30 | 119 | 62.33d | 0d |
| 121 | 2.1.5.9 | Install Herculite in Pan area | 30min | 2009-06-17 09:30 | 2009-06-17 10:00 | 120 | 62.33d | 0d |
| 122 | 2.1.5.10 | Install pan 4th location to ceiling | 2h | 2009-06-17 10:00 | 2009-06-17 12:00 | 121 | 62.33d | 0d |
| 123 | 2.1.5.11 | Install Herculite in Pan area | 30min | 2009-06-17 13:00 | 2009-06-17 13:30 | 122 | 62.33d | 0d |
| 124 | 2.1.5.12 | Install pan 5th location to ceiling | 2h | 2009-06-18 07:00 | 2009-06-18 09:00 | 123 | 62.33d | 0d |
| 125 | 2.1.5.13 | Install Herculite in Pan area | 30min | 2009-06-18 09:00 | 2009-06-18 09:30 | 124 | 62.33d | 0d |
| 126 | 2.1.5.14 | Install pan 6th location to ceiling | 2h | 2009-06-18 09:30 | 2009-06-18 11:30 | 125 | 62.33d | 0d |
| 127 | 2.1.5.15 | Install Herculite in Pan area | 30min | 2009-06-18 11:30 | 2009-06-18 12:00 | 126 | 62.33d | 0d |
| 128 | 2.1.5.16 | Install pan 7th location to ceiling | 2h | 2009-06-18 13:00 | 2009-06-19 08:30 | 127 | 62.33d | 0d |
| 129 | 2.1.5.17 | Install Herculite in Pan area | 30min | 2009-06-19 08:30 | 2009-06-19 09:00 | 128 | 62.33d | 0d |
| 130 | 2.1.5.18 | Install pan 8th location to ceiling | 2h | 2009-06-19 09:00 | 2009-06-19 11:00 | 129 | 62.33d |  |
| 131 | 2.1.5.19 | remove pan first location from ceiling | 1h | 2009-07-08 08:00 | 2009-07-08 09:00 | 156SS+1d | 46.08d | 0d |
| 132 | 2.1.5.20 | remove Herculite from first Pan area | 30min | 2009-07-08 09:00 | 2009-07-08 09:30 | 131 | 46.08d | 0d |
| 133 | 2.1.5.21 | remove pan second location from ceiling | 1h | 2009-07-08 09:30 | 2009-07-08 10:30 | 132 | 46.08d | 0d |
| 134 | 2.1.5.22 | remove Herculite from second Pan area | 30min | 2009-07-08 10:30 | 2009-07-08 11:00 | 133 | 46.08d | 0d |
| 135 | 2.1.5.23 | remove pan third location from ceiling | 1h | 2009-07-08 11:00 | 2009-07-08 12:00 | 134 | 46.08d | 0d |
| 136 | 2.1.5.24 | remove Herculite from third Pan area | 30min | 2009-07-08 13:00 | 2009-07-08 13:30 | 135 | 46.08d | 0d |
| 137 | 2.1.5.25 | remove pan forth location from ceiling | 1h | 2009-07-09 07:00 | 2009-07-09 08:00 | 136 | 46.08d | 0d |
| 138 | 2.1.5.26 | remove Herculite from forth Pan area | 30min | 2009-07-09 08:00 | 2009-07-09 08:30 | 137 | 46.08d | 0d |
| 139 | 2.1.5.27 | remove pan fifth location from ceiling | 1h | 2009-07-09 08:30 | 2009-07-09 09:30 | 138 | 46.08d | 0d |
| 140 | 2.1.5.28 | remove Herculite from fifth Pan area | 30min | 2009-07-09 09:30 | 2009-07-09 10:00 | 139 | 46.08d | 0d |
| 141 | 2.1.5.29 | remove pan sixth location from ceiling | 1h | 2009-07-09 10:00 | 2009-07-09 11:00 | 140 | 46.08d | 0d |
| 142 | 2.1.5.30 | remove Herculite from sixth Pan area | 30min | 2009-07-09 11:00 | 2009-07-09 11:30 | 141 | 46.08d | 0d |
| 143 | 2.1.5.31 | remove pan seventh location from ceiling | 1h | 2009-07-09 11:30 | 2009-07-09 13:30 | 142 | 46.08d | 0d |
| 144 | 2.1.5.32 | remove Herculite from seventh Pan area | 30min | 2009-07-10 07:00 | 2009-07-10 07:30 | 143 | 46.08d | 0d |
| 145 | 2.1.5.33 | remove pan eighth location from ceiling | 1h | 2009-07-10 07:30 | 2009-07-10 08:30 | 144 | 46.08d | 0d |
| 146 | 2.1.5.34 | remove Herculite from eigth Pan area | 30min | 2009-07-10 08:30 | 2009-07-10 09:00 | 145 | 46.08d | 0d |
| 147 | 2.1.5.35 | Remove Lead blankets | 8h | 2009-07-10 09:00 | 2009-07-13 11:30 | 146 | 46.08d | 0d |
| 148 | 2.1.5.36 | Transport out of Tunnel | 1.5d | 2009-07-13 11:30 | 2009-07-15 09:30 | 147 | 46.08d |  |
| 149 | 2.1.5.37 | As found Survey MI14 RR and MI | 5d | 2009-08-28 08:30 | 2009-09-04 11:00 | 161, 41 | 11.92d |  |
| 150 | 2.1.5.38 | Final Sheilding survey to run beam | 1d | 2009-09-14 08:00 | 2009-09-15 08:30 | 152, 163, 173 | 5.92d |  |

| ID | WBS | Task | Duration | Start | Finish | Predecessors | Total slack | Free slack |
| --- | --- | --- | --- | --- | --- | --- | --- | --- |
| 151 | 2.1.6 | **Contractor MI14 Area** | 55d | 2009-06-22 08:00 | 2009-09-14 08:00 |  | 5.92d |  |
| 152 | 2.1.6.1 | **Conduit Installation** | 40d | 2009-06-22 08:00 | 2009-08-20 11:30 |  | 8.92d |  |
| 153 | 2.1.6.1.1 | Strip topsoil | 2d | 2009-06-22 08:00 | 2009-06-24 09:00 | 95 | 8.92d | 3d |
| 154 | 2.1.6.1.2 | Excavation of Berm | 5d | 2009-06-29 10:30 | 2009-07-07 07:30 | 153, 96 | 5.92d | 0d |
| 155 | 2.1.6.1.3 | Vacate MI14 area in Tunnel | 1d | 2009-07-06 07:00 | 2009-07-07 07:30 | 154SS+4d | 5.92d | 0d |
| 156 | 2.1.6.1.4 | Core holes in Ceiling | 10d | 2009-07-07 07:30 | 2009-07-21 13:30 | 155 | 5.92d | 0d |
| 157 | 2.1.6.1.5 | Install support frames | 10d | 2009-07-07 07:30 | 2009-07-21 13:30 | 156SS | 10.92d | 0d |
| 158 | 2.1.6.1.6 | Install 14 conduits | 10d | 2009-07-14 10:00 | 2009-07-29 09:30 | 157SS+5d | 10.92d | 0d |
| 159 | 2.1.6.1.7 | FBP Enclosure Cap beams | 10d | 2009-07-14 10:00 | 2009-07-29 09:30 | 158SS | 10.92d | 0d |
| 160 | 2.1.6.1.8 | Water proof top of enclosure | 5d | 2009-07-29 09:30 | 2009-08-05 12:00 | 159 | 10.92d | 0d |
| 161 | 2.1.6.1.9 | Backfill berm | 10d | 2009-08-05 13:00 | 2009-08-20 11:30 | 160 | 10.92d | 0d |
| 162 | 2.1.6.1.10 | Vacate MI14 area in tunnel | 1d | 2009-08-07 07:00 | 2009-08-10 07:30 | 161SS+1d | 28.92d |  |
| 163 | 2.1.6.2 | **Concrete Foundation Installation** | 20d | 2009-08-05 13:00 | 2009-09-04 11:00 |  | 10.92d | 5d |
| 164 | 2.1.6.2.1 | FBP Deep Footing | 5d | 2009-08-05 13:00 | 2009-08-13 09:00 | 161SS | 10.92d | 0d |
| 165 | 2.1.6.2.2 | FBP Deep Wall | 5d | 2009-08-13 09:00 | 2009-08-20 11:30 | 164 | 10.92d | 0d |
| 166 | 2.1.6.2.3 | FBP Remaining Footings | 5d | 2009-08-13 09:00 | 2009-08-20 11:30 | 165SS | 10.92d | 0d |
| 167 | 2.1.6.2.4 | FBP Remaining Walls | 5d | 2009-08-20 11:30 | 2009-08-28 08:30 | 166 | 10.92d | 0d |
| 168 | 2.1.6.2.5 | FBP Transformer Foundation | 5d | 2009-08-20 11:30 | 2009-08-28 08:30 | 167SS | 10.92d | 0d |
| 169 | 2.1.6.2.6 | FBP Air Switch Foundation | 5d | 2009-08-20 11:30 | 2009-08-28 08:30 | 168SS | 10.92d | 0d |
| 170 | 2.1.6.2.7 | Backfill and install Under slab Conduits | 5d | 2009-08-20 11:30 | 2009-08-28 08:30 | 169SS | 10.92d | 0d |
| 171 | 2.1.6.2.8 | FBP Floor Slab | 5d | 2009-08-28 08:30 | 2009-09-04 11:00 | 170 | 10.92d |  |
| 172 | 2.1.6.2.9 | Construction of Foundation and Floor Slab for MI-14 bldg | 10d | 2009-08-05 13:00 | 2009-08-20 11:30 | 161SS | 20.92d |  |
| 173 | 2.1.6.3 | **Utility Installation** | 45d | 2009-07-07 07:30 | 2009-09-14 08:00 |  | 5.92d | 0d |
| 174 | 2.1.6.3.1 | Install Communication Handholes and Ductbank | 10d | 2009-07-07 07:30 | 2009-07-21 13:30 | 156SS | 5.92d | 0d |
| 175 | 2.1.6.3.2 | Install Power Manholes and Ductbank | 15d | 2009-07-07 07:30 | 2009-07-29 09:30 | 174SS | 5.92d | 0d |
| 176 | 2.1.6.3.3 | Install ICW Piping | 10d | 2009-07-29 09:30 | 2009-08-13 09:00 | 175 | 15.92d | 0d |
| 177 | 2.1.6.3.4 | Reroute ICW Piping | 10d | 2009-07-29 09:30 | 2009-08-13 09:00 | 176SS | 15.92d | 10d |
| 178 | 2.1.6.3.5 | Install HV Feeder Cable and Terminate | 20d | 2009-07-29 09:30 | 2009-08-28 08:30 | 175 | 5.92d | 0d |
| 179 | 2.1.6.3.6 | Install Hardstand | 10d | 2009-08-28 08:30 | 2009-09-14 08:00 | 177, 178 | 5.92d |  |
